# Cronograma

Schedule from MS Project, 2020-12-01 to 2021-04-30, costs in S.

## Calendars

- Estándar: Mon-Sun 07:00-12:00, 13:00-16:00.

## Resources

| Resource | Group | Rate | Cost per use |
| --- | --- | --- | --- |
| OPERADOR DE EQUIPO LIVIANO | Mano de Obra | 18.83 |  |
| TOPOGRAFO | Mano de Obra | 23.8 |  |
| INGENIERO ESPECIALISTA EN MEDO AMBIENTE | Mano de Obra | 4000 |  |
| INGENIERO ESPECIALISTA EN SEGURIDAD INDUSTRIAL | Mano de Obra | 4000 |  |
| CAPACITADOR | Mano de Obra | 4000 |  |
| OPERARIO | Mano de Obra | 23.8 |  |
| OFICIAL | Mano de Obra | 18.83 |  |
| PEON | Mano de Obra | 17.01 |  |
| OPERADOR DE MOTOFURGON (OFICIAL) | Mano de Obra | 18.83 |  |
| OPERADOR DE MARTILLO NEUMATICO | Mano de Obra | 18.83 |  |
| OPERARIO EQUIPO LIVIANO | Mano de Obra | 18.83 |  |
| CLAVOS PARA MADERA C/C 3" | Material |  | 3.84 |
| CLAVOS PARA MADERA C/C 4" | Material |  | 3.84 |
| CLAVOS PARA MADERA S/C 3/4" | Material |  | 3.84 |
| CLAVOS Fo No C/C 3/4" | Material |  | 4.19 |
| CLAVOS CON CABEZA DE 3 " | Material |  | 4.85 |
| ALAMBRE NEGRO N°16 | Material |  | 5.17 |
| ALAMBRE NEGRO N°8 | Material |  | 5.17 |
| CLAVOS PARA CALAMINA 2 1/2" | Material |  | 0.2 |
| ACERO CORRUGADO F'Y=4200 KG/CM2 GRADO 60 | Material |  | 2.8 |
| ARENA FINA | Material |  | 50 |
| ARENA FINA PARA SELLADO | Material |  | 50 |
| COMPOST | Material |  | 1.75 |
| PIEDRA CHANCADA 1/2" | Material |  | 110 |
| PIEDRA CHANCADA DE 3/4" | Material |  | 110 |
| PIEDRA MEDIANA DE (MAX. 4") | Material |  | 60 |
| AFIRMADO | Material |  | 55 |
| ARENA GRUESA | Material |  | 60 |
| AFICHE | Material |  | 3 |
| CONFITILLO 1/2"-3/4" | Material |  | 70 |
| REUBICACION DE POSTES DE LUZ | Material |  | 2180 |
| LINTERNAS | Material |  | 33.9 |
| ASFALTO RC-250 | Material |  | 16.65 |
| CEMENTO PORTLAND TIPO I (42.5KG) | Material |  | 21.19 |
| CEMENTO PORTLAND TIPO MS (42.5KG) | Material |  | 26.63 |
| HIPOCLORITO DE SODIO 5% (4 L) | Material |  | 16.95 |
| CINTA SEÑALADORA | Material |  | 0.1 |
| TECKNOPORT E= 1" (1.20x2.40) | Material |  | 11.8 |
| BALDE PLASTICOS | Material |  | 4.24 |
| INSTALACION DE LAVADEROS - TANQUE 1100 L 04 LAVADEROS TUBERIA SOPORTE E INSTALACION. | Material |  | 3250 |
| JABON LIQUIDO (FRASCO 400 ML) | Material |  | 11.86 |
| ALCOHOL 70% (FRASCO 1 L) | Material |  | 8.7 |
| ALCOHOL EN GEL FRASCO 1 L | Material |  | 11.86 |
| ELABORACION DEL PLAN PARA LA VIGILANCIA PREVENCION Y CONTROL DEL COVID-19 | Material |  | 3500 |
| YESO DE 28 Kg | Material |  | 12.29 |
| BARRENO DE PERFORACION 7/8" X 5' | Material |  | 1440 |
| CURADOR QUIMICO | Material |  | 29.13 |
| SOLVENTE PARA LACA PROTECTORA | Material |  | 69.49 |
| TENSIOMETRO DIGITAL | Material |  | 415.25 |
| OXIMETRO | Material |  | 186.44 |
| CAMILLA TÓPICA | Material |  | 593.22 |
| ESTETOSCOPIO | Material |  | 305.08 |
| PEGAMENTO PARA PVC | Material |  | 142.38 |
| CINTA TEFLON | Material |  | 1.28 |
| ESCOBAS | Material |  | 5.93 |
| TERMOMETRO LASER INFRAROJO O AFINES | Material |  | 423.73 |
| BALANZA DIGITAL C/TALLIMETRO | Material |  | 311.36 |
| STICKER PARA SEÑALETICA DE SEGURIDAD | Material |  | 5 |
| EXTINTOR C.I. POLVO QUIMICO SECO DE 6 kg TIPO ABC | Material |  | 350 |
| ADITIVO MEJORADOR DE ADHERENCIA | Material |  | 77.49 |
| PINTURA BASE (25kg) | Material |  | 44.39 |
| ASPERSOR MOCHILA ASPERSOR O SIMILAR | Material |  | 381.36 |
| WINCHA | Material |  | 16 |
| OVEROL DE PROTECCION BIOLOGICA | Material |  | 50.84 |
| BOLSAS PLÁSTICAS | Material |  | 1.27 |
| CAJA DE CONCRETO P/MEDIDOR AGUA | Material |  | 20 |
| CAJA DE REGISTRO INTERMEDIA DE CONCRETO SIMPLE PARA DESAGUE 12"x24" | Material |  | 30 |
| MOVILIZACION Y DESMOVILIZACION | Material |  | 7500 |
| HORMIGON (PUESTO EN OBRA) | Material |  | 60 |
| ENERGIA PROVISIONAL PARA LA OBRA | Material |  | 200 |
| BOTIQUIN DE PRIMEROS AUXILIOS ABASTECIDO EN OBRA | Material |  | 350 |
| DISCO DE CORTE | Material |  | 24.5 |
| COLA SINTETICA | Material |  | 23.67 |
| LIJA PARA MADERA | Material |  | 1.9 |
| LIJA PARA PARED | Material |  | 1.9 |
| CILINDROS PARA DEPOSITOS DE BASURA | Material |  | 100 |
| AGUA | Material |  | 16 |
| PROGRAMA DE MONITOREO AMBIENTAL | Material |  | 3500 |
| MEDIDAS DE PREVENCION Y MITIGACION | Material |  | 3500 |
| AGUA P/MITIG. DE CONTAMINACION-POLVO | Material |  | 16 |
| AGUA (PURIFICADA EN ENVASE DE 20 L) | Material |  | 11.86 |
| TRAPEADOR INDUSTRIAL | Material |  | 25.42 |
| HUMUS (GUANO LOMBRIS) | Material |  | 5 |
| PAPEL TOALLA | Material |  | 10.17 |
| FICHAS SINTOMATOLOGICAS (COPIAS) | Material |  | 0.17 |
| SILLA DE MADERA | Material |  | 76.27 |
| PRUEBA RAPIDA PARA DETECCION DE COVID-19 | Material |  | 90 |
| SEÑALES DE OBLIGACION PREVENCION PROHIBICION E INFORMACION SURTIDA | Material |  | 1000 |
| IZAJE DE CARTEL DE OBRA | Material |  | 93.44 |
| RECIPIENTE PEDILUVIO O TAPETE DESINFECTANTE | Material |  | 29.66 |
| MADERA NACIONAL P/ENCOFRADO-CARP | Material |  | 5.5 |
| GIGANTOGRAFIA PARA CARTEL DE OBRA 13 oz. 3.60x2.40 m. (RESOLUCION 600 DPI) SEGUN DISEÑO | Material |  | 35 |
| MADERA TORNILLO | Material |  | 6.78 |
| REGLA DE ALUMINIO 1 1/2"x4"x10' | Material |  | 150 |
| ARBOL PONCIANA | Material |  | 15 |
| SUMINISTRO Y COLOCACION DE SEÑAL PREVENTIVA | Material |  | 624.28 |
| POSTES DE MADERA PARA CINTA | Material |  | 15 |
| ESTACA DE MADERA | Material |  | 6 |
| PIE DERECHO DIAMETRO 2" L= 2.40 M. | Material |  | 10.5 |
| PIE DERECHO DIAMETRO 3" L= 3.00 M. | Material |  | 13.5 |
| LEÑA | Material |  | 0.5 |
| MADERA PARA CARTEL DE OBRA | Material |  | 4.5 |
| ESCRITORIO | Material |  | 296.61 |
| TRIPLAY LUPUNA DE 4'x8'x 19 mm | Material |  | 80.51 |
| TRIPLAY DE 4'x8'x 6 mm | Material |  | 37.9 |
| TRIPLAY DE 6 MM | Material |  | 30 |
| MALLA PROTECTORA | Material |  | 46.61 |
| PLACA RECORDATORIA | Material |  | 1200 |
| MASCARILLA COMUNITARIA O EQUIVALENTE | Material |  | 2.55 |
| LENTES DE PROTECCION | Material |  | 10 |
| CARETA DE PROTECCION FACIAL | Material |  | 12.72 |
| MARCO Y TAPA PARA CAJA DE REGISTRO DE CONCRETO SIMPLE PARA DESAGUE 12"x24" | Material |  | 31.15 |
| PETROLEO DIESEL # 2 | Material |  | 13.5 |
| ALQUILER DE 02 MODULO DE SS.HH. PORTATIL P/PERSONAL | Material |  | 2240 |
| PETROLEO | Material |  | 13.5 |
| DISOLVENTE XILOL | Material |  | 16.94 |
| PINTURA DE TRAFICO | Material |  | 43.43 |
| LACA PROTECTORA ENCOFRADO P/CONCRETO CAR | Material |  | 122.88 |
| CALAMINA GALVANIZADA 2.40m.x0.80m.x0.6mm. | Material |  | 30.88 |
| TUBERIA PVC SAP A-10 DE 1/2" | Material |  | 2.73 |
| ADOQUINES DE CONCRETO 10X20X8 | Material |  | 48.22 |
| TEODOLITO | Equipo | 15 |  |
| HERRAMIENTAS MANUALES | Equipo | 8 |  |
| BOTAS DE JEBE | Equipo | 21.5 |  |
| CASCO AMARILLO | Equipo | 19.8 |  |
| CORREA DE SEGURIDAD | Equipo | 29.2 |  |
| ESCOBA | Equipo | 12 |  |
| BOTAS DE CUERO CON PUNTA DE ACERO | Equipo | 52.23 |  |
| GUANTES DE JEBE | Equipo | 10.2 |  |
| PROTECTOR DE OIDOS | Equipo | 3.4 |  |
| ANTEOJOS P/SOLD. | Equipo | 15.97 |  |
| CHALECOS FLUORESCENTES | Equipo | 7.3 |  |
| UNIFORME CAMISA Y PANTALON DRILL | Equipo | 150 |  |
| MASCARA CONTRA POLVO | Equipo | 1.3 |  |
| ARNES DE SEGURIDAD | Equipo | 60.17 |  |
| DEPOSITO PARA AGUA | Equipo | 500 |  |
| CAMION CISTERNA 4x2 (AGUA) 122 HP 2 000 | Equipo | 80 |  |
| CAMION VOLQUETE 15 M3. | Equipo | 130 |  |
| MOTOBOMBA 10 HP 4" INC. MANGUERA Y ACCES | Equipo | 20 |  |
| MOTOFURGON | Equipo | 15 |  |
| CAMION CISTERNA 4X2 (AGUA) 2 000 GAL. | Equipo | 100 |  |
| EQUIPO DE CORTE | Equipo | 25 |  |
| MOCHILA PULVORIZADORA | Equipo | 5 |  |
| COMPACTADOR VIBR. TIPO PLANCHA 7 HP | Equipo | 12.61 |  |
| RODILLO LISO VIBR AUTOP 101-135HP 10-12T | Equipo | 149.71 |  |
| CARGADOR S/LLANTAS 100-115 HP 2-2.25 YD3 | Equipo | 220 |  |
| TRACTOR DE ORUGAS DE 190-240 HP | Equipo | 324.95 |  |
| MINICARGADOR FRONTAL 64 HP | Equipo | 150 |  |
| MARTILLO NEUMATICO DE 25/29 Kg. | Equipo | 15 |  |
| VIBRADOR DE CONCRETO 4 HP 2.40" | Equipo | 18.75 |  |
| MOTONIVELADORA DE 125 HP | Equipo | 169.49 |  |
| MEZCLADORA CONCRETO TAMBOR 18HP 11P3 | Equipo | 25 |  |
| GRUPO ELECTROGENO A GASOLINA 5 500 W. | Equipo | 25 |  |
| NIVEL | Equipo | 6 |  |
| HERRAMIENTAS MANUALES | Equipo | 8 |  |
| ALQUILER DE INMUEBLE PARA ALMACEN PRINCIPAL DE OBRA Y OFICINA | Subcontrato |  | 600 |
| ALQUILER DE INMUEBLE PARA OFICINA DE RESIDENTE Y/O SUPERVISOR | Subcontrato |  | 350 |
| RIEGO Y MANTENIMIENTO DE PLANTONES | Subcontrato |  | 500 |

## Schedule

| ID | WBS | Task | Duration | Start | Finish | Predecessors | Total slack | Constraint | Resources | Work | Cost | Text1 | Text8 | Text3 | Text4 | Text2 | Text6 |
| --- | --- | --- | --- | --- | --- | --- | --- | --- | --- | --- | --- | --- | --- | --- | --- | --- | --- |
| 1 | 1 | **"MEJORAMIENTO DE PISTAS Y VEREDAS EN EL AA.HH. HERMANOS CARCAMO I ETAPA-DISTRITO DE PAITA-PROVINCIA DE PAITA - DEPARTAMENTO DE PIURA"** | 150d? | 2020-12-01 | 2021-04-30 |  | 0d |  |  | 21756147h | 3,514,536.94 |  |  |  |  |  |  |
| 2 | 1.1 | **OBRAS PROVISIONALES** | 148d? | 2020-12-01 | 2021-04-28 |  | 0d |  |  | 21739341h | 264,379.82 | 01 | 000000000000548 |  |  |  |  |
| 3 | 1.1.1 | CARTEL DE IDENTIFICACION DE OBRA DE 4.80x3.60m. (Impresión de banner y soporte de madera) | 1d? | 2020-12-01 | 2020-12-02 |  | 0d | start no earlier than 2020-12-01 | CEMENTO PORTLAND TIPO I (42.5KG) [233.4%]; COLA SINTETICA [65%]; OPERARIO [58%]; OFICIAL [8%]; PEON [102%]; MEZCLADORA CONCRETO TAMBOR 18HP 11P3 [4%]; CLAVOS PARA MADERA C/C 3" [48.1%]; CLAVOS PARA MADERA C/C 4" [59.2%]; ALAMBRE NEGRO N°16 [58%]; CLAVOS PARA CALAMINA 2 1/2" [11639%]; GIGANTOGRAFIA PARA CARTEL DE OBRA 13 oz. 3.60x2.40 m. (RESOLUCION 600 DPI) SEGUN DISEÑO [1900%]; PIEDRA MEDIANA DE (MAX. 4") [25.2%]; HORMIGON (PUESTO EN OBRA) [53.4%]; AGUA [8.2%]; MADERA PARA CARTEL DE OBRA [5848%]; LIJA PARA MADERA [300%]; IZAJE DE CARTEL DE OBRA | 13.76h | 1,451.96 | 01.01 | 000000000000643 | 1451.96 | 1451.96 |  |  |
| 4 | 1.1.2 | MOVILIZACION Y DESMOVILIZACION DE EQUIPO | 2d | 2020-12-01 | 2020-12-03 | 3SS | 146d | start no earlier than 2020-12-01 | MOVILIZACION Y DESMOVILIZACION | 16h | 7,500 | 01.02 | 000000000000550 | 7500 | 7500 |  |  |
| 5 | 1.1.3 | ALQUILER DE LOCAL PARA ALMACEN PRINCIPAL DE OBRA Y OFICINA | 2d | 2020-12-01 | 2020-12-03 | 3SS | 146d | start no earlier than 2020-12-01 | ALQUILER DE INMUEBLE PARA ALMACEN PRINCIPAL DE OBRA Y OFICINA [600%]; ALQUILER DE INMUEBLE PARA OFICINA DE RESIDENTE Y/O SUPERVISOR [600%] | 192h | 5,700 | 01.03 | 000000000000644 | 950 | 5700 |  |  |
| 6 | 1.1.4 | ENERGIA PROVISIONAL PARA LA OBRA | 148d | 2020-12-01 | 2021-04-28 | 3SS | 0d | start no earlier than 2020-12-01 | ENERGIA PROVISIONAL PARA LA OBRA [800%] | 9472h | 1,200 | 01.07 | 000000000000553 | 200 | 1600 |  |  |
| 7 | 1.1.5 | TRANQUERAS DE MADERA 1.20X1.10M P/DESVIO TRANSITO VEHICULAR | 148d | 2020-12-01 | 2021-04-28 | 3SS | 0d | start no earlier than 2020-12-01 | PINTURA DE TRAFICO [128%]; OPERARIO; PEON [50%]; CLAVOS Fo No C/C 3/4" [320%]; TRIPLAY DE 6 MM [1120%]; MADERA NACIONAL P/ENCOFRADO-CARP [15680%] | 1776h | -2,268.08 | 01.08 | 000000000000554 | 342.82 | 5485.12 | 16 |  |
| 8 | 1.1.6 | **SEGURIDAD Y SALUD** | 148d | 2020-12-01 | 2021-04-28 |  | 0d |  |  | 2607.8h | 38,094.48 | 01.09 | 000000000000555 |  |  |  |  |
| 9 | 1.1.6.1 | ELABORACION, IMPLEMENTACION Y ADMINISTRACION DEL PLAN DE SEGURIDAD Y SALUD EN EL TRABAJO | 30d | 2020-12-01 | 2020-12-31 | 3SS | 118d | start no earlier than 2020-12-01 | INGENIERO ESPECIALISTA EN MEDO AMBIENTE [6.2%]; INGENIERO ESPECIALISTA EN SEGURIDAD INDUSTRIAL [6.2%]; CAPACITADOR [6.2%]; AFICHE [18000%] | 45h | 37,620 | 01.09.01 | 000000000000556 | 6270 | 37620 |  |  |
| 10 | 1.1.6.2 | SUMINISTRO DE DEPOSITOS DE BASURA | 1d | 2020-12-01 | 2020-12-02 | 3SS | 147d | start no earlier than 2020-12-01 | CILINDROS PARA DEPOSITOS DE BASURA [400%] | 32h | 400 | 01.09.02 | 000000000000557 | 100 | 400 |  |  |
| 11 | 1.1.6.3 | SUMINISTRO DE IMPLEMENTOS DE SEGURIDAD | 1d | 2020-12-01 | 2020-12-02 | 3SS | 147d | start no earlier than 2020-12-01 | UNIFORME CAMISA Y PANTALON DRILL [187.5%]; GUANTES DE JEBE [187.5%]; PROTECTOR DE OIDOS [187.5%]; CHALECOS FLUORESCENTES [187.5%]; MASCARA CONTRA POLVO [187.5%]; BOTAS DE JEBE [187.5%]; CASCO AMARILLO [187.5%]; CORREA DE SEGURIDAD [62.5%]; BOTAS DE CUERO CON PUNTA DE ACERO [187.5%]; ANTEOJOS P/SOLD. [187.5%]; ARNES DE SEGURIDAD [25%] | 142h | 4,491.84 | 01.09.03 | 000000000000558 | 4491.84 | 4491.84 |  |  |
| 12 | 1.1.6.4 | SUMINISTRO E INSTALACION DE STIKER PARA SEÑALETICA DE SEGURIDAD | 2d | 2020-12-01 | 2020-12-03 | 3SS | 146d | start no earlier than 2020-12-01 | PEON; STICKER PARA SEÑALETICA DE SEGURIDAD [2000%] | 16h | 236 | 01.09.04 | 000000000000559 | 11.8 | 236 | 20 | 20 |
| 13 | 1.1.6.5 | SUMINISTRO E INSTALACION DE EXTINTOR DE POLVO QUIMICO SECO | 1d | 2020-12-01 | 2020-12-02 | 3SS | 147d | start no earlier than 2020-12-01 | PEON [60%]; EXTINTOR C.I. POLVO QUIMICO SECO DE 6 kg TIPO ABC [300%] | 4.8h | 1,131.66 | 01.09.05 | 000000000000560 | 377.22 | 1131.66 |  |  |
| 14 | 1.1.6.6 | SEÑALIZACION TEMPORAL AMBIENTAL Y SEGURIDAD | 148d | 2020-12-01 | 2021-04-28 | 3SS | 0d | start no earlier than 2020-12-01 | OPERARIO; PEON; CINTA SEÑALADORA [12000%]; MALLA PROTECTORA [3198%]; POSTES DE MADERA PARA CINTA [3000%] | 2368h | -5,785.02 | 01.09.06 | 000000000000561 | 668.23 | 4009.38 |  |  |
| 15 | 1.1.7 | **MITIGACION AMBIENTAL** | 3d | 2020-12-01 | 2020-12-04 |  |  |  |  | 9519.14h | 66,559.26 | 01.10 | 000000000000624 |  |  |  |  |
| 16 | 1.1.7.1 | PLAN DE MANEJO DE MITIGACION AMBIENTAL | 30d | 2020-12-01 | 2020-12-31 | 3SS | 118d | start no earlier than 2020-12-01 | PROGRAMA DE MONITOREO AMBIENTAL; MEDIDAS DE PREVENCION Y MITIGACION | 480h | 7,000 | 01.10.01 | 000000000000625 | 7000 | 7000 |  |  |
| 17 | 1.1.7.2 | RIEGO DE ZONA DE TRABAJO PARA MITIGAR LA CONTAMINACION -POLVO (Inc. costo de agua y transp. surtidor a obra) | 60d | 2020-12-01 | 2021-01-30 | 3SS | 88d | start no earlier than 2020-12-01 | PEON [200%]; MOTOBOMBA 10 HP 4" INC. MANGUERA Y ACCES [99.1%]; CAMION CISTERNA 4X2 (AGUA) 2 000 GAL. [99.1%]; AGUA P/MITIG. DE CONTAMINACION-POLVO [149616%] | 1911.14h | 42,619.26 | 01.10.02 | 000000000000646 | 1.9 | 42619.26 | 22431.19 | 1500 |
| 18 | 1.1.7.3 | ALQUILER DE 02 MODULOS DE SS.HH. PORTATIL P/PERSONAL | 148d | 2020-12-01 | 2021-04-28 | 3SS | 0d | start no earlier than 2020-12-01 | ALQUILER DE 02 MODULO DE SS.HH. PORTATIL P/PERSONAL [600%] | 7104h | 13,440 | 01.10.03 | 000000000000627 | 2240 | 13440 |  |  |
| 19 | 1.1.7.4 | ELABORACION DEL PLAN PARA LA VIGILANCIA, PREVENCION Y CONTROL DEL COVID-19 | 3d | 2020-12-01 | 2020-12-04 | 3SS | 145d | start no earlier than 2020-12-01 | ELABORACION DEL PLAN PARA LA VIGILANCIA PREVENCION Y CONTROL DEL COVID-19 | 24h | 3,500 | 01.10.04 | 000000000000629 | 3500 | 3500 |  |  |
| 20 | 1.1.8 | **PREVENCION COVID-19** | 148d | 2020-12-01 | 2021-04-28 |  | 0d |  |  | 21715744h | 146,142.2 | 01.11 | 000000000000628 |  |  |  |  |
| 21 | 1.1.8.1 | ZONA CONTROL PREVIO EN OBRA (EVALUACIÓN MÉDICA BÁSICA) | 148d | 2020-12-01 | 2021-04-28 | 3SS | 0d | start no earlier than 2020-12-01 | TENSIOMETRO DIGITAL; OXIMETRO; TERMOMETRO LASER INFRAROJO O AFINES; PRUEBA RAPIDA PARA DETECCION DE COVID-19 [36000%] | 429792h | 33,425.42 | 01.11.01 | 000000000000630 | 33425.42 | 33425.42 |  |  |
| 22 | 1.1.8.2 | ZONA DE CONTROL DE DESINFECCION | 148d | 2020-12-01 | 2021-04-28 | 3SS | 0d | start no earlier than 2020-12-01 | INSTALACION DE LAVADEROS - TANQUE 1100 L 04 LAVADEROS TUBERIA SOPORTE E INSTALACION.; HIPOCLORITO DE SODIO 5% (4 L) [49200%]; JABON LIQUIDO (FRASCO 400 ML) [34200%]; ALCOHOL 70% (FRASCO 1 L) [18000%]; ALCOHOL EN GEL FRASCO 1 L [18000%]; ASPERSOR MOCHILA ASPERSOR O SIMILAR; AGUA (PURIFICADA EN ENVASE DE 20 L) [46800%]; RECIPIENTE PEDILUVIO O TAPETE DESINFECTANTE [800%] | 1979648h | 25,515.44 | 01.11.02 | 000000000000631 | 25515.44 | 25515.44 |  |  |
| 23 | 1.1.8.3 | ZONA DE VESTUARIO | 148d | 2020-12-01 | 2021-04-28 | 3SS | 0d | start no earlier than 2020-12-01 | OVEROL DE PROTECCION BIOLOGICA [72000%]; MASCARILLA COMUNITARIA O EQUIVALENTE [936000%]; LENTES DE PROTECCION [72000%]; CARETA DE PROTECCION FACIAL [96000%] | 13923840h | 79,884 | 01.11.03 | 000000000000632 | 79884 | 79884 |  |  |
| 24 | 1.1.8.4 | OTRAS MEDIDAS ADOPTADAS DURANTE LA EJECUCIÓN DE OBRA | 148d | 2020-12-01 | 2021-04-28 | 3SS | 0d | start no earlier than 2020-12-01 | BALDE PLASTICOS [200%]; LINTERNAS; CAMILLA TÓPICA; ESTETOSCOPIO; ESCOBAS [1000%]; BALANZA DIGITAL C/TALLIMETRO; BOLSAS PLÁSTICAS [31200%]; BOTIQUIN DE PRIMEROS AUXILIOS ABASTECIDO EN OBRA; TRAPEADOR INDUSTRIAL [200%]; PAPEL TOALLA [31200%]; FICHAS SINTOMATOLOGICAS (COPIAS) [390000%]; SILLA DE MADERA; SEÑALES DE OBLIGACION PREVENCION PROHIBICION E INFORMACION SURTIDA; ESCRITORIO | 5382464h | 7,317.34 | 01.11.04 | 000000000000633 | 7317.34 | 7317.34 |  |  |

| ID | WBS | Task | Duration | Start | Finish | Predecessors | Total slack | Free slack | Constraint | Resources | Work | Cost | Text1 | Text8 | Text2 | Text3 | Text4 | Text6 |
| --- | --- | --- | --- | --- | --- | --- | --- | --- | --- | --- | --- | --- | --- | --- | --- | --- | --- | --- |
| 25 | 1.2 | **OBRAS PRELIMINARES** | 50d | 2020-12-01 | 2021-01-20 |  | 29d |  |  |  | 2735.99h | 47,580.16 | 02 | 000000000000562 |  |  |  |  |
| 26 | 1.2.1 | TALA Y ELIMINACION DE ARBOLES | 8d | 2020-12-01 | 2020-12-09 | 3SS | 142d |  | start no earlier than 2020-12-01 | OPERARIO; PEON [200%] | 192h | 2,859 | 02.01 | 000000000000636 | 60 | 47.65 | 2859 | 10 |
| 27 | 1.2.2 | DEMOLICION DE VEREDA DE CONCRETO E= 0.10m. (CON EQUIPO) | 8d | 2020-12-01 | 2020-12-09 | 3SS | 142d |  | start no earlier than 2020-12-01 | PETROLEO DIESEL # 2 [5042.6%]; PEON [382%]; OPERADOR DE MARTILLO NEUMATICO [191%]; MARTILLO NEUMATICO DE 25/29 Kg. [191%]; GRUPO ELECTROGENO A GASOLINA 5 500 W. [95.5%]; BARRENO DE PERFORACION 7/8" X 5' [420.2%] | 550.1h | 20,506.64 | 02.02 | 000000000000647 | 2101.09 | 9.76 | 20506.64 | 200 |
| 28 | 1.2.3 | CONTROL ALTIMETRICO PERMANENTE EN OBRA C/EQUIPO | 50d | 2020-12-01 | 2021-01-20 |  | 29d | 13d | start no earlier than 2020-12-01 | YESO DE 28 Kg [33646.8%]; NIVEL; TOPOGRAFO; PEON [199.4%]; TEODOLITO; ESTACA DE MADERA [44862.4%]; WINCHA [6729.4%] | 1993.88h | 24,214.52 | 02.04 | 000000000000680 | 22431.19 | 1.64 | 36787.15 | 500 |
| 29 | 1.3 | **MOVIMIENTO DE TIERRAS** | 63d | 2020-12-01 | 2021-02-02 |  | 16d |  |  |  | 4030.6h | 1,031,155.97 | 03 | 000000000000568 |  |  |  |  |
| 30 | 1.3.1 | **EXCAVACIONES** | 63d | 2020-12-01 | 2021-02-02 |  | 16d |  |  |  | 525.9h | 105,086.84 | 03.01 | 000000000000569 |  |  |  |  |
| 31 | 1.3.1.1 | CORTE DE TERRENO A NIVEL DE SUBRASANTE C/EQUIPO PESADO | 10d | 2020-12-01 | 2020-12-11 |  | 16d | 0d | start no earlier than 2020-12-01 | PEON [399.2%]; TRACTOR DE ORUGAS DE 190-240 HP | 399.17h | 50,454.93 | 03.01.01 | 000000000000570 | 6386.7 | 7.9 | 50454.93 | 400 |
| 32 | 1.3.1.2 | CORTE EN T.N COMPACTADO PARA VEREDAS, RAMPAS Y MARTILLOS | 10d | 2020-12-11 | 2020-12-21 | 31 | 16d | 0d | start no earlier than 2020-12-01 | PEON | 79.81h | 29,920.89 | 03.01.02 | 000000000000571 | 640.43 | 46.72 | 29920.89 |  |
| 33 | 1.3.1.3 | EXCAVACION PARA UÑAS, SARDINELES Y CUNETA MANUAL | 3d | 2021-01-30 | 2021-02-02 | 44, 39 | 16d | 0d | start no earlier than 2020-12-01 | PEON | 23.94h | 22,958.26 | 03.01.03 | 000000000000572 | 511.74 | 46.72 | 23908.49 |  |
| 34 | 1.3.1.4 | EXCAVACION MANUAL P/HOYOS DE PLANTONES PROF. H=0.60M | 3d | 2020-12-10 | 2020-12-13 | 53 | 115d | 99d | start no earlier than 2020-12-01 | PEON [95.8%] | 22.98h | 1,752.76 | 03.01.04 | 000000000000662 | 57.46 | 35.04 | 2013.4 |  |
| 35 | 1.3.2 | **RELLENOS** | 40d | 2020-12-21 | 2021-01-30 |  | 16d |  |  |  | 3504.7h | 926,069.13 | 03.02 | 000000000000573 |  |  |  |  |
| 36 | 1.3.2.1 | **EN PISTAS** | 40d | 2020-12-21 | 2021-01-30 |  | 16d |  |  |  | 2238.34h | 561,487.44 | 03.02.01 | 000000000000574 |  |  |  |  |
| 37 | 1.3.2.1.1 | CONFORMACIÓN Y COMPACTACIÓN SUB-BASE CON MATERIAL GRANULAR E=20CM. C/EQUIPO PESADO | 15d | 2020-12-21 | 2021-01-05 | 32 | 16d | 0d | start no earlier than 2020-12-01 | OPERARIO [95.9%]; PEON [383.5%]; CAMION CISTERNA 4x2 (AGUA) 122 HP 2 000 [95.9%]; RODILLO LISO VIBR AUTOP 101-135HP 10-12T [95.9%]; MOTONIVELADORA DE 125 HP [95.9%]; AGUA [46980.8%] | 920.44h | 34,094.62 | 03.02.01.01 | 000000000000575 | 13423.08 | 2.54 | 34094.62 | 2000 |
| 38 | 1.3.2.1.2 | SUB-BASE GRANULAR E=0.15m INC/COMPACTACION AL 95% (afirmado con piedra chancada 1/2" al 25%) | 15d | 2021-01-05 | 2021-01-20 | 37 | 16d | 0d | start no earlier than 2020-12-01 | PEON [375.2%]; CAMION CISTERNA 4x2 (AGUA) 122 HP 2 000 [94.6%]; RODILLO LISO VIBR AUTOP 101-135HP 10-12T [94.6%]; MOTONIVELADORA DE 125 HP [94.6%]; AFIRMADO [157050%]; ARENA GRUESA [104700%]; AGUA [26846.2%] | 790.74h | 192,621.2 | 03.02.01.02 | 000000000000637 | 13423.08 | 14.35 | 192621.2 | 1300 |
| 39 | 1.3.2.1.3 | BASE GRANULAR E=0.20m INC/COMPACTACION AL 100% (afirmado con piedra chancada 1/2" al 40%) | 10d | 2021-01-20 | 2021-01-30 | 38 | 16d | 0d | start no earlier than 2020-12-01 | PEON [375.2%]; CAMION CISTERNA 4x2 (AGUA) 122 HP 2 000 [94.6%]; RODILLO LISO VIBR AUTOP 101-135HP 10-12T [94.6%]; MOTONIVELADORA DE 125 HP [94.6%]; PIEDRA CHANCADA 1/2" [174500%]; AFIRMADO [104700%]; ARENA GRUESA [69800%]; AGUA [26846.2%] | 527.16h | 334,771.62 | 03.02.01.03 | 000000000000577 | 13423.08 | 24.94 | 334771.62 | 1300 |
| 40 | 1.3.2.2 | **EN VEREDAS,MARTILLOS, RAMPAS Y CUNETAS** | 28d | 2020-12-21 | 2021-01-18 |  | 28d |  |  |  | 1266.36h | 364,581.69 | 03.02.02 | 000000000000578 |  |  |  |  |
| 41 | 1.3.2.2.1 | CONFORMACIÓN Y COMPACTACIÓN SUBRASANTE MANUAL | 7d | 2020-12-21 | 2020-12-28 | 32 | 28d | 0d | start no earlier than 2020-12-01 | OPERARIO [98.5%]; PEON [197.3%]; COMPACTADOR VIBR. TIPO PLANCHA 7 HP [98.5%]; AGUA [19468.1%] | 220.85h | 28,184.57 | 03.02.02.01 | 000000000000580 | 6489.36 | 4.6 | 29851.06 | 140 |
| 42 | 1.3.2.2.2 | BASE GRANULAR COMPACTADO E=0.10m | 7d | 2021-01-04 | 2021-01-11 | 43 | 28d | 0d | start no earlier than 2020-12-01 | OFICIAL; PEON [199.4%]; COMPACTADOR VIBR. TIPO PLANCHA 7 HP; AFIRMADO [25308.5%]; AGUA [3244.7%] | 223.32h | 62,613.52 | 03.02.02.02 | 000000000000582 | 6489.36 | 9.89 | 64179.77 | 70 |
| 43 | 1.3.2.2.3 | ACARREO Y ACOPIO CON MOTOFURGON DE MATERIAL EXCEDENTE | 7d | 2020-12-28 | 2021-01-04 | 41 | 28d | 0d | start no earlier than 2020-12-01 | PEON [399%]; OPERADOR DE MOTOFURGON (OFICIAL); MOTOFURGON | 335.15h | 123,455.07 | 03.02.02.03 | 000000000000583 | 9789.56 | 12.86 | 125893.74 | 65 |
| 44 | 1.3.2.2.4 | ELIMINACION DE MATERIAL EXCEDENTE CON VOLQUETE DE 15 m3 D<= 10 Km. EN ZONA URBANA | 7d | 2021-01-11 | 2021-01-18 | 42 | 28d | 12d | start no earlier than 2020-12-01 | PEON [386.6%]; CAMION VOLQUETE 15 M3. [386.6%]; CARGADOR S/LLANTAS 100-115 HP 2-2.25 YD3 [96.5%] | 487.05h | 150,328.53 | 03.02.02.04 | 000000000000649 | 9789.56 | 17.27 | 169065.7 | 375 |
| 45 | 1.4 | **VEREDAS, MARTILLOS Y RAMPAS** | 18d | 2020-12-01 | 2020-12-19 |  | 115d |  |  |  | 3493.86h | 624,051.24 | 04 | 000000000000585 |  |  |  |  |
| 46 | 1.4.1 | **UÑAS DE CONCRETO P/VEREDAS, MARTILLOS Y RAMPAS** | 8d | 2020-12-01 | 2020-12-09 |  | 142d |  |  |  | 957.11h | 217,908.36 | 04.01 | 000000000000586 |  |  |  |  |
| 47 | 1.4.1.1 | CONCRETO F'C=175 KG/CM2, P/ UÑAS DE VEREDAS, MARTILLOS Y RAMPAS | 8d | 2020-12-01 | 2020-12-09 |  | 142d |  | start no earlier than 2020-12-01 | CEMENTO PORTLAND TIPO MS (42.5KG) [366095%]; OPERADOR DE EQUIPO LIVIANO [199.4%]; OPERARIO [199.4%]; OFICIAL; PEON [797.6%]; VIBRADOR DE CONCRETO 4 HP 2.40"; MEZCLADORA CONCRETO TAMBOR 18HP 11P3; ARENA GRUESA [20673.6%]; CONFITILLO 1/2"-3/4" [31010.4%]; AGUA [12921%]; REGLA DE ALUMINIO 1 1/2"x4"x10' [430.7%] | 957.11h | 217,908.36 | 04.01.02 | 000000000000588 | 430.7 | 505.94 | 217908.36 | 12 |
| 48 | 1.4.2 | **VEREDAS, MARTILLOS Y RAMPAS DE CONCRETO** | 18d | 2020-12-01 | 2020-12-19 |  | 115d |  |  |  | 2536.75h | 406,142.88 | 04.02 | 000000000000591 |  |  |  |  |
| 49 | 1.4.2.1 | ENCOFRADO Y DESENCOFRADO EN VEREDAS Y MARTILLOS | 9d | 2020-12-01 | 2020-12-10 |  | 132d | 0d | start no earlier than 2020-12-01 | SOLVENTE PARA LACA PROTECTORA [11614.8%]; LACA PROTECTORA ENCOFRADO P/CONCRETO CAR [2158.5%]; OPERARIO [98.9%]; OFICIAL [98.9%]; PEON [98.9%]; CLAVOS CON CABEZA DE 3 " [9969.8%]; ALAMBRE NEGRO N°8 [9969.8%]; MADERA TORNILLO [107175%]; TRIPLAY LUPUNA DE 4'x8'x 19 mm [3788.5%] | 213.63h | 39,535.24 | 04.02.01 | 000000000000592 | 498.49 | 79.31 | 39535.24 | 14 |
| 50 | 1.4.2.2 | ENCOFRADO Y DESENCOFRADO EN JUNTA TRANSVERSAL EN VEREDAS Y MARTILLOS | 9d | 2020-12-01 | 2020-12-10 |  | 132d | 0d | start no earlier than 2020-12-01 | OPERARIO [97.4%]; OFICIAL [97.4%]; PEON [97.4%]; CLAVOS CON CABEZA DE 3 " [4365.4%]; ALAMBRE NEGRO N°8 [4365.4%]; MADERA TORNILLO [46928.1%] | 210.46h | 11,280.19 | 04.02.02 | 000000000000593 | 218.27 | 51.68 | 11280.19 | 14 |
| 51 | 1.4.2.3 | VEREDAS Y MARTILLOS F'C=175 KG/CM2, E=10CM, ACABADO FROTACHADO Y BRUÑADO | 9d | 2020-12-10 | 2020-12-19 | 49, 50 | 132d |  | start no earlier than 2020-12-01 | CEMENTO PORTLAND TIPO MS (42.5KG) [550125%]; OPERADOR DE EQUIPO LIVIANO [198.1%]; OPERARIO [198.1%]; OFICIAL [99.1%]; PEON [792.4%]; VIBRADOR DE CONCRETO 4 HP 2.40" [99.1%]; MEZCLADORA CONCRETO TAMBOR 18HP 11P3 [99.1%]; ARENA GRUESA [30905.9%]; CONFITILLO 1/2"-3/4" [44504.5%]; AGUA [18543.5%]; REGLA DE ALUMINIO 1 1/2"x4"x10' [618.1%] | 1069.82h | 320,061.5 | 04.02.03 | 000000000000594 | 6181.18 | 51.78 | 320061.5 | 120 |
| 52 | 1.4.2.4 | RAMPAS DE CONCRETO 175 kg/cm2 E=10CM BRUÑADO S/DISEÑO | 9d | 2020-12-10 | 2020-12-19 | 49, 50 | 132d |  | start no earlier than 2020-12-01 | CEMENTO PORTLAND TIPO MS (42.5KG) [27428%]; OPERADOR DE EQUIPO LIVIANO [96.3%]; OPERARIO [192.6%]; OFICIAL [96.3%]; PEON [770.5%]; VIBRADOR DE CONCRETO 4 HP 2.40" [48.2%]; MEZCLADORA CONCRETO TAMBOR 18HP 11P3 [96.3%]; ARENA FINA [339%]; ARENA GRUESA [1540.9%]; CONFITILLO 1/2"-3/4" [2465.4%]; AGUA [616.4%] | 936.1h | 18,305.89 | 04.02.04 | 000000000000595 | 308.18 | 59.4 | 18305.89 | 80 |
| 53 | 1.4.2.5 | JUNTA CON ASFALTO DE E=1", A. max=4" P/VEREDAS, MARTILLOS Y RAMPAS | 9d | 2020-12-01 | 2020-12-10 |  | 115d | 0d | start no earlier than 2020-12-01 | ASFALTO RC-250 [36398.9%]; PETROLEO [7044.9%]; OPERARIO [98.9%]; PEON [49.4%]; TECKNOPORT E= 1" (1.20x2.40) [9654.2%]; ARENA GRUESA [704.5%]; LEÑA [521848%] | 106.74h | 16,960.06 | 04.02.06 | 000000000000597 | 2609.24 | 6.5 | 16960.06 | 120 |

| ID | WBS | Task | Duration | Start | Finish | Predecessors | Total slack | Free slack | Constraint | Resources | Work | Cost | Text1 | Text8 | Text2 | Text3 | Text4 | Text6 |
| --- | --- | --- | --- | --- | --- | --- | --- | --- | --- | --- | --- | --- | --- | --- | --- | --- | --- | --- |
| 54 | 1.5 | **SARDINELES** | 23d | 2021-02-02 | 2021-02-25 |  | 16d |  |  |  | 1274.81h | 176,760.24 | 05 | 000000000000598 |  |  |  |  |
| 55 | 1.5.1 | SARDINELES - CONCRETO F'C = 175 KG/CM2 | 7d | 2021-02-09 | 2021-02-16 | 56, 57, 58 | 16d | 0d | start no earlier than 2020-12-01 | CEMENTO PORTLAND TIPO MS (42.5KG) [125630%]; OPERADOR DE EQUIPO LIVIANO [192%]; OPERARIO [192%]; OFICIAL [96%]; PEON [767.8%]; VIBRADOR DE CONCRETO 4 HP 2.40" [96%]; MEZCLADORA CONCRETO TAMBOR 18HP 11P3 [96%]; ARENA GRUESA [7094.4%]; CONFITILLO 1/2"-3/4" [10641.6%]; AGUA [4434%] | 806.18h | 68,279.31 | 05.01 | 000000000000599 | 147.8 | 476.72 | 70459.22 | 14 |
| 56 | 1.5.2 | SARDINEL PERALTADO, ENCOFRADO Y DESENCOFRADO CARAVISTA | 7d | 2021-02-02 | 2021-02-09 | 33, 28 | 16d | 0d | start no earlier than 2020-12-01 | SOLVENTE PARA LACA PROTECTORA [23795.4%]; LACA PROTECTORA ENCOFRADO P/CONCRETO CAR [4422.1%]; OPERARIO; OFICIAL; CLAVOS CON CABEZA DE 3 " [13276.4%]; ALAMBRE NEGRO N°8 [26552.8%]; MADERA TORNILLO [342122%]; TRIPLAY LUPUNA DE 4'x8'x 19 mm [7761.6%] | 111.7h | 75,508.85 | 05.02 | 000000000000600 | 1021.26 | 74.27 | 75848.98 | 16 |
| 57 | 1.5.3 | SARDINEL SUMERGIDO, ENCOFRADO Y DESENCOFRADO | 7d | 2021-02-02 | 2021-02-09 | 33, 28 | 16d | 0d | start no earlier than 2020-12-01 | OPERARIO; OFICIAL; CLAVOS CON CABEZA DE 3 " [1455%]; ALAMBRE NEGRO N°8 [2909.9%]; MADERA TORNILLO [37493.2%] | 111.92h | 4,879.15 | 05.03 | 000000000000601 | 111.92 | 46.64 | 5219.95 | 16 |
| 58 | 1.5.4 | SARDINEL.- ACERO FY=4200 kg/cm2 | 7d | 2021-02-02 | 2021-02-09 | 33, 28 | 16d | 0d | start no earlier than 2020-12-01 | OPERARIO [98.4%]; OFICIAL [98.4%]; ALAMBRE NEGRO N°16 [21635.6%]; ACERO CORRUGADO F'Y=4200 KG/CM2 GRADO 60 [454348%] | 110.26h | 20,477.72 | 05.04 | 000000000000638 | 4327.12 | 4.81 | 20813.45 | 220 |
| 59 | 1.5.5 | SARDINEL, CURADO QUIMICO DE CONCRETO | 8d | 2021-02-16 | 2021-02-24 | 55 | 16d | 0d | start no earlier than 2020-12-01 | CURADOR QUIMICO [11381.5%]; OFICIAL [94%]; MOCHILA PULVORIZADORA [94%] | 120.38h | 4,982.81 | 05.05 | 000000000000602 | 1552.73 | 3.44 | 5341.39 | 150 |
| 60 | 1.5.6 | JUNTA CON ASFALTO DE E=1". A.max=8" P/SARDINELES | 1d | 2021-02-24 | 2021-02-25 | 59 | 16d | 0d | start no earlier than 2020-12-01 | ASFALTO RC-250 [5817.7%]; PETROLEO [1379%]; OPERARIO [89.8%]; PEON [89.8%]; TECKNOPORT E= 1" (1.20x2.40) [3189%]; ARENA GRUESA [1292.8%] | 14.37h | 2,632.39 | 05.06 | 000000000000651 | 430.94 | 8.15 | 3512.16 | 120 |
| 61 | 1.6 | **RESALTO DE CONCRETO** | 13d? | 2021-04-01 | 2021-04-14 |  | 16d |  |  |  | 696.91h | 38,372.98 | 06 | 000000000000675 |  |  |  |  |
| 62 | 1.6.1 | RESALTO,ENCOFRADO Y DESENCOFRADO | 5d? | 2021-04-01 | 2021-04-06 | 77 | 16d | 0d | start no earlier than 2020-12-01 | OPERARIO [95.9%]; OFICIAL [95.9%]; PEON [95.9%]; CLAVOS CON CABEZA DE 3 " [1342.8%]; ALAMBRE NEGRO N°8 [1342.8%]; MADERA TORNILLO [14435.1%] | 115.09h | 3,469.8 | 06.01 | 000000000000676 | 67.14 | 51.68 | 3469.8 | 14 |
| 63 | 1.6.2 | RESALTO,CONCRETO F'C = 210 KG/CM2 | 5d | 2021-04-06 | 2021-04-11 | 62 | 16d | 0d | start no earlier than 2020-12-01 | CEMENTO PORTLAND TIPO MS (42.5KG) [72173.4%]; OPERARIO [185.2%]; OFICIAL [92.6%]; PEON [741%]; OPERARIO EQUIPO LIVIANO [185.2%]; VIBRADOR DE CONCRETO 4 HP 2.40" [92.6%]; MEZCLADORA CONCRETO TAMBOR 18HP 11P3 [92.6%]; ARENA GRUESA [3112.2%]; CONFITILLO 1/2"-3/4" [6298.5%]; AGUA [1363.4%] | 555.75h | 34,342.39 | 06.02 | 000000000000677 | 74.1 | 463.46 | 34342.39 | 20 |
| 64 | 1.6.3 | RESALTO, CURADO QUIMICO DE CONCRETO | 3d | 2021-04-11 | 2021-04-14 | 63 | 16d |  | start no earlier than 2020-12-01 | CURADOR QUIMICO [1194.9%]; OFICIAL [54.3%]; MOCHILA PULVORIZADORA [54.3%] | 26.07h | 560.79 | 06.03 | 000000000000678 | 163.02 | 3.44 | 560.79 | 150 |
| 65 | 1.7 | **PAVIMENTO SEMIRIGIDO** | 25d | 2021-02-25 | 2021-03-22 |  | 16d |  |  |  | 926.71h | 998,676.69 | 07 | 000000000000604 |  |  |  |  |
| 66 | 1.7.1 | CAMA DE ARENA E=0.05 m | 5d | 2021-02-25 | 2021-03-02 | 60 | 16d | 0d | start no earlier than 2020-12-01 | OPERARIO [99.3%]; OFICIAL [99.3%]; PEON [198.5%]; ARENA GRUESA [86462%] | 158.83h | 87,690.95 | 07.01 | 000000000000605 | 13301.85 | 7.05 | 93778.04 | 200 |
| 67 | 1.7.2 | PAVIMENTO DE ADOQUIN VEHICULAR 0.20x0.10x0.08m | 15d | 2021-03-02 | 2021-03-17 | 66 | 16d | 0d | start no earlier than 2020-12-01 | OPERARIO; OFICIAL; PEON [199.8%]; EQUIPO DE CORTE; ADOQUINES DE CONCRETO 10X20X8; DISCO DE CORTE [53207.4%] | 599.12h | 870,872.12 | 07.02 | 000000000000606 | 13301.85 | 65.47 | 870872.12 | 60 |
| 68 | 1.7.3 | COMPACTACION Y SELLADO DE PAVIMENTO | 5d | 2021-03-17 | 2021-03-22 | 67 | 16d | 0d | start no earlier than 2020-12-01 | OFICIAL [99.3%]; PEON [198.5%]; COMPACTADOR VIBR. TIPO PLANCHA 7 HP [99.3%]; ARENA FINA PARA SELLADO [11306.6%]; ESCOBA [24.8%] | 168.75h | 40,113.62 | 07.03 | 000000000000607 | 13301.85 | 3.22 | 42831.96 | 200 |
| 69 | 1.8 | **PINTURA** | 7d | 2021-04-01 | 2021-04-08 |  | 22d |  |  |  | 511.28h | 84,251.5 | 08 | 000000000000608 |  |  |  |  |
| 70 | 1.8.1 | PINTURA DE TRAFICO PARA SARDINELES PERALTADOS | 7d | 2021-04-01 | 2021-04-08 | 77 | 22d |  | start no earlier than 2020-12-01 | PINTURA BASE (25kg) [2629.8%]; DISOLVENTE XILOL [9861.7%]; PINTURA DE TRAFICO [19723.4%]; OPERARIO; PEON [50%]; ADITIVO MEJORADOR DE ADHERENCIA [24419.5%]; LIJA PARA PARED [5635.3%] | 83.93h | 53,882.83 | 08.01 | 000000000000609 | 1878.42 | 29.51 | 55432.17 | 20 |
| 71 | 1.8.2 | PINTADO DE PASE PEATONAL | 7d | 2021-04-01 | 2021-04-08 | 77 | 22d |  | start no earlier than 2020-12-01 | DISOLVENTE XILOL [4623.3%]; PINTURA DE TRAFICO [9246.6%]; OPERARIO [97.8%]; PEON [97.8%] | 109.59h | 17,686.1 | 08.02 | 000000000000639 | 880.63 | 22.26 | 19602.82 | 20 |
| 72 | 1.8.3 | PINTADO DE SEÑALES HORIZONTALES EN PAVIMENTO | 7d | 2021-04-01 | 2021-04-08 | 77 | 22d |  | start no earlier than 2020-12-01 | DISOLVENTE XILOL [1011.1%]; PINTURA DE TRAFICO [2022.3%]; OPERARIO [96.3%]; PEON [96.3%] | 107.86h | 5,640.41 | 08.03 | 000000000000640 | 192.6 | 39.08 | 7526.81 | 10 |
| 73 | 1.8.4 | PINTADO DE RESALTO | 7d | 2021-04-01 | 2021-04-08 | 77 | 22d |  | start no earlier than 2020-12-01 | DISOLVENTE XILOL [855.9%]; PINTURA DE TRAFICO [1715%]; OPERARIO [90.6%]; PEON [90.6%] | 101.43h | 1,856.37 | 08.04 | 000000000000679 | 163.02 | 22.27 | 3630.46 | 20 |
| 74 | 1.8.5 | PINTADO DE LINEAS DE CARRIL | 7d | 2021-04-01 | 2021-04-08 | 77 | 22d |  | start no earlier than 2020-12-01 | DISOLVENTE XILOL [152.5%]; PINTURA DE TRAFICO [508.5%]; OPERARIO [96.9%]; PEON [96.9%] | 108.47h | 5,185.79 | 08.05 | 000000000000641 | 508.47 | 13.93 | 7082.99 | 25 |
| 75 | 1.9 | **AREAS VERDES** | 10d | 2021-03-22 | 2021-04-01 |  | 16d |  |  |  | 159.41h | 13,161.44 | 09 | 000000000000610 |  |  |  |  |
| 76 | 1.9.1 | SEMBRADO DE PLANTONES INC. TAPADO HOYOS PROF. H=0.60M | 5d | 2021-03-22 | 2021-03-27 | 34, 68 | 16d | 0d | start no earlier than 2020-12-01 | PEON [98.5%]; COMPOST [212800%]; HUMUS (GUANO LOMBRIS) [53200%]; AGUA [266%]; ARBOL PONCIANA [26600%] | 39.41h | 11,661.44 | 09.01 | 000000000000661 | 266 | 43.84 | 11661.44 | 30 |
| 77 | 1.9.2 | RIEGO Y MANTENIMIENTO DE PLANTONES | 5d | 2021-03-27 | 2021-04-01 | 76 | 16d | 0d | start no earlier than 2020-12-01 | RIEGO Y MANTENIMIENTO DE PLANTONES [300%] | 120h | 1,500 | 09.02 | 000000000000663 |  | 500 | 1500 |  |

| ID | WBS | Task | Duration | Start | Finish | Predecessors | Total slack | Free slack | Constraint | Resources | Work | Cost | Text1 | Text8 | Text2 | Text3 | Text4 | Text6 |
| --- | --- | --- | --- | --- | --- | --- | --- | --- | --- | --- | --- | --- | --- | --- | --- | --- | --- | --- |
| 78 | 1.10 | **OTROS** | 150d? | 2020-12-01 | 2021-04-30 |  | 0d |  |  |  | 2223.9h | 96,611.43 | 10 | 000000000000615 |  |  |  |  |
| 79 | 1.10.1 | REUBICACION DE POSTES DE LUZ | 7d | 2020-12-01 | 2020-12-08 | 3SS | 141d |  | start no earlier than 2020-12-01 | REUBICACION DE POSTES DE LUZ [3600%] | 2016h | 78,480 | 10.01 | 000000000000616 | 36 | 2180 | 78480 |  |
| 80 | 1.10.2 | SEÑAL PREVENTIVA 0.60 X 0.60 (SOBRE TUBO DE ACERO) | 3d | 2020-12-01 | 2020-12-04 | 3SS | 145d |  | start no earlier than 2020-12-01 | SUMINISTRO Y COLOCACION DE SEÑAL PREVENTIVA [700%] | 168h | 4,369.96 | 10.02 | 000000000000654 |  | 624.28 | 4369.96 |  |
| 81 | 1.10.3 | PLACA RECORDATORIA. INC. PODIO | 1d? | 2021-04-28 | 2021-04-29 | 4, 5, 6, 7, 9, 10, 11, 12, 13, 14, 16, 17, 18, 19, 21, 22, 23, 24, 79, 80, 89, 90 | 0d |  | start no earlier than 2020-12-01 | PLACA RECORDATORIA | 8h | 1,200 | 10.03 | 000000000000617 |  | 1200 | 1200 |  |
| 82 | 1.10.4 | LIMPIEZA FINAL DE OBRA | 2d | 2021-04-28 | 2021-04-30 | 81SS | 0d |  | start no earlier than 2020-12-01 | PEON [199.4%] | 31.9h | 12,561.47 | 10.04 | 000000000000618 | 22431.19 | 0.56 | 12561.47 | 500 |
| 83 | 1.11 | **VARIOS** | 20d | 2021-03-22 | 2021-04-11 |  | 17d |  |  |  | 753.16h | 139,535.48 | 11 | 000000000000620 |  |  |  |  |
| 84 | 1.11.1 | NIVELACION DE BUZONES EN GENERAL | 5d | 2021-03-22 | 2021-03-27 | 68 | 27d | 10d | start no earlier than 2020-12-01 | CEMENTO PORTLAND TIPO MS (42.5KG) [2850%]; OPERARIO [95%]; OFICIAL [95%]; PEON [475%]; ACERO CORRUGADO F'Y=4200 KG/CM2 GRADO 60 [19000%]; PIEDRA CHANCADA DE 3/4" [209%]; ARENA GRUESA [190%]; AGUA [95%] | 266h | 6,793.07 | 11.01 | 000000000000621 | 19 | 612.89 | 11644.91 |  |
| 85 | 1.11.2 | NIVELACION DE CAJA DE DESAGUE | 5d | 2021-03-22 | 2021-03-27 | 68 | 27d | 10d | start no earlier than 2020-12-01 | CEMENTO PORTLAND TIPO MS (42.5KG) [3186%]; OPERARIO [98.3%]; PEON [98.3%]; ARENA GRUESA [2124%]; AGUA [118%]; CAJA DE REGISTRO INTERMEDIA DE CONCRETO SIMPLE PARA DESAGUE 12"x24" [23600%]; MARCO Y TAPA PARA CAJA DE REGISTRO DE CONCRETO SIMPLE PARA DESAGUE 12"x24" [23600%] | 78.67h | 30,842.45 | 11.02 | 000000000000622 | 236 | 137.49 | 32447.64 |  |
| 86 | 1.11.3 | NIVELACION DE CAJA DE AGUA | 5d | 2021-03-22 | 2021-03-27 | 68 | 17d | 0d | start no earlier than 2020-12-01 | CEMENTO PORTLAND TIPO MS (42.5KG) [3540%]; PEGAMENTO PARA PVC [1180%]; OPERARIO [98.3%]; PEON [98.3%]; TUBERIA PVC SAP A-10 DE 1/2" [23600%]; ARENA FINA [7080%]; ARENA GRUESA [708%]; AGUA [236%]; CINTA TEFLON [23600%]; CAJA DE CONCRETO P/MEDIDOR AGUA [23600%] | 78.67h | 26,559.05 | 11.03 | 000000000000623 | 236 | 119.34 | 28164.24 |  |
| 87 | 1.11.4 | REPOSICION DE CONEXIÓN DOMICILIARIA DE AGUA POTABLE | 5d | 2021-03-27 | 2021-04-01 | 68, 86 | 17d | 0d | start no earlier than 2020-12-01 | CEMENTO PORTLAND TIPO MS (42.5KG) [3186%]; OPERARIO [98.3%]; PEON [98.3%]; ARENA GRUESA [2124%]; AGUA [118%]; CAJA DE REGISTRO INTERMEDIA DE CONCRETO SIMPLE PARA DESAGUE 12"x24" [23600%]; MARCO Y TAPA PARA CAJA DE REGISTRO DE CONCRETO SIMPLE PARA DESAGUE 12"x24" [23600%] | 78.67h | 30,842.45 | 11.02 | 000000000000622 | 236 | 137.49 | 32447.64 |  |
| 88 | 1.11.5 | REPOSICION DE CONEXIÓN DOMICILIARIA DE DESAGUE | 5d | 2021-04-01 | 2021-04-06 | 68, 87 | 17d | 0d | start no earlier than 2020-12-01 | CEMENTO PORTLAND TIPO MS (42.5KG) [3540%]; PEGAMENTO PARA PVC [1180%]; OPERARIO [98.3%]; PEON [98.3%]; TUBERIA PVC SAP A-10 DE 1/2" [23600%]; ARENA FINA [7080%]; ARENA GRUESA [708%]; AGUA [236%]; CINTA TEFLON [23600%]; CAJA DE CONCRETO P/MEDIDOR AGUA [23600%] | 78.67h | 26,559.05 | 11.03 | 000000000000623 | 236 | 119.34 | 28164.24 |  |
| 89 | 1.11.6 | ACARREO DE AGREGADOS 50M<D<100M | 5d | 2021-04-06 | 2021-04-11 | 84, 85, 87, 88 | 17d |  | start no earlier than 2020-12-01 | PEON [191.5%]; MINICARGADOR FRONTAL 64 HP [24.1%] | 86.25h | 8,969.71 | 11.04 | 000000000000653 | 4599.85 | 1.95 | 8969.71 | 300 |
| 90 | 1.11.7 | ACARREO DE CEMENTO DMÁX <= 100M | 5d | 2021-04-06 | 2021-04-11 | 84, 85, 87, 88 | 17d |  | start no earlier than 2020-12-01 | PEON [191.5%]; MINICARGADOR FRONTAL 64 HP [24.1%] | 86.25h | 8,969.71 | 11.04 | 000000000000653 | 4599.85 | 1.95 | 8969.71 | 300 |
